Schedule from GanttProject, 2015-01-23 to 2015-06-09.

## Calendars

- Project calendar: Mon-Fri working; Sat-Sun off.

## Resources

| Resource |
| --- |
| Joe |
| Bill |
| Hal |
| Daniel |

## Schedule

| ID | WBS | Task | Type | Duration | Start | Finish | Predecessors |
| --- | --- | --- | --- | --- | --- | --- | --- |
| 1 | 1 | Initial specs receieved | milestone | 0d | 2015-01-23 | 2015-01-23 |  |
| 2 | 2 | Initial quote |  | 1d | 2015-01-23 | 2015-01-23 | 1 |
| 3 | 3 | PO RECEIVED | milestone | 0d | 2015-01-26 | 2015-01-26 | 2 |
| 4 | 4 | CREATE PROJECT FOLDER |  | 1d | 2015-01-26 | 2015-01-26 | 3 |
| 5 | 5 | FILLOUT IQ FORM |  | 1d | 2015-01-27 | 2015-01-27 | 4 |
| 6 | 6 | **REVIEW PROJECT FOLDER** |  | 1d | 2015-01-27 | 2015-01-27 | 4 |
| 7 | 6.1 | Voltage documented |  | 1d | 2015-01-27 | 2015-01-27 |  |
| 8 | 6.2 | Quotes in place |  | 1d | 2015-01-27 | 2015-01-27 |  |
| 9 | 6.3 | RFQ where necessary |  | 1d | 2015-01-27 | 2015-01-27 |  |
| 10 | 6.4 | Fill out Sales Review Form |  | 1d | 2015-01-27 | 2015-01-27 |  |
| 11 | 6.5 | Identify customizations |  | 1d | 2015-01-27 | 2015-01-27 |  |
| 12 | 6.6 | Attach Proj Mgt Progress sheet to Proj Folder |  | 1d | 2015-01-27 | 2015-01-27 |  |
| 13 | 6.7 | Clear delivery dates |  | 1d | 2015-01-27 | 2015-01-27 |  |
| 14 | 6.8 | Complete Req for Purchase Order form |  | 1d | 2015-01-27 | 2015-01-27 |  |
| 15 | 7 | LAYOUT SKETCH |  | 1d | 2015-01-23 | 2015-01-23 | 1 |
| 16 | 8 | AIRFLOW CALCULATION |  | 1d | 2015-01-26 | 2015-01-26 | 3, 15 |
| 17 | 9 | **DUCT LAYOUT DRAWING** |  | 1d | 2015-01-27 | 2015-01-27 | 16 |
| 18 | 9.1 | Review Sales Order Review Checklist |  | 1d | 2015-01-27 | 2015-01-27 |  |
| 19 | 10 | CUSTOMER REVIEW LAYOUT |  | 1d | 2015-01-28 | 2015-01-28 | 17 |
| 20 | 11 | LAYOUT APPROVED | milestone | 0d | 2015-01-29 | 2015-01-29 | 19 |
| 21 | 12 | 1st DEPOSIT RECEIVED |  | 1d | 2015-01-29 | 2015-01-29 | 20 |
| 22 | 13 | ORDER MATERIAL |  | 1d | 2015-01-30 | 2015-01-30 | 21 |
| 23 | 14 | MATERIAL LEAD (8-12wks lead) |  | 84d | 2015-02-02 | 2015-05-28 | 22 |
| 24 | 15 | 2nd Deposit received |  | 1d | 2015-01-30 | 2015-01-30 | 21 |
| 25 | 16 | Release shipments |  | 1d | 2015-05-29 | 2015-05-29 | 23, 24 |
| 26 | 17 | CHECK DELIVERY DATES |  | 1d | 2015-05-29 | 2015-05-29 | 23 |
| 27 | 18 | Notify Customer of delivery dates |  | 1d | 2015-06-01 | 2015-06-01 | 26 |
| 28 | 19 | SCHEDULE INSTALL |  | 1d | 2015-06-01 | 2015-06-01 | 26 |
| 29 | 20 | Create Project Install Folder |  | 1d | 2015-06-02 | 2015-06-02 | 28 |
| 30 | 21 | INSTALL |  | 5d | 2015-06-03 | 2015-06-09 | 29 |
