# Installations

Schedule from GanttProject, 2014-12-01 to 2015-11-06.

## Calendars

- Project calendar: Mon-Sat working; Sun off. Exceptions (off unless hours are given): 2015-04-03 (Good Friday), 2015-05-25 (Memorial Day), 2015-07-03 (July 4), 2015-09-07 (Labor Day).

## Resources

| Resource |
| --- |
| Jason Boyette |
| Mike Taylor |
| Mark Prodswick |
| Curtis Richardson CJ |
| Outside Contractor |
| John |

## Schedule

| ID | Task | Duration | Start | Finish | Predecessors | Complete | Resources | SO | Location | REP | I/PM |
| --- | --- | --- | --- | --- | --- | --- | --- | --- | --- | --- | --- |
| 1 | ELG UTICA | 8d | 2015-02-09 | 2015-02-17 |  | 100% | Jason/Mark | 22316 | Monroe NC | ME | Install |
| 2 | ELG Utica delivery | 1d | 2015-02-11 | 2015-02-11 |  | 100% | Daniel |  |  |  |  |
| 3 | Bonney Forge 22329 | 2d | 2015-02-09 | 2015-02-10 |  | 100% | Mike/CJ | 22329 | MT Union PA | MC | Install |
| 4 | Bonney Forge 21755 | 3d | 2015-02-11 | 2015-02-13 | 3 | 100% | Mike/CJ | 21755 | MT Union PA | MC | Install |
| 5 | Bonney Forge 1 drop | 2d | 2015-02-23 | 2015-02-24 |  | 100% | Mike/CJ | 21755 | MT Union PA | MC | Install |
| 6 | Haun Derrick | 5d | 2015-02-20 | 2015-02-25 |  | 100% | Mike/CJ | 22291 | Cheektowaga, NY | MC | Install |
| 7 | Stage booths | 2d | 2015-03-05 | 2015-03-06 |  | 100% | Mike/CJ | Free | Avani | ES | Construct |
| 8 | Spanda booths | 4d | 2015-03-02 | 2015-03-05 |  | 100% | Jason/Mark | 22050 | Sacramento CA | ES | Install |
| 9 | Local 92 site visit | 1d | 2015-03-06 | 2015-03-06 | 8 | 100% | Jason | 21709 | Bloomington CA | MH | PM |
| 10 | San Bernardino | 1d | 2015-03-07 | 2015-03-07 | 9 | 100% | Jason | Free | San bernardino | MH | PM |
| 11 | Local 502 | 5d | 2015-03-09 | 2015-03-13 |  | 100% | Jason | 21714 | Pullyup WA | ES | PM |
| 12 | Honda | 3d | 2015-03-09 | 2015-03-11 |  | 100% | Bill |  | Atlanta GA | CS | PM |
| 13 | Wolf-tech | 2d | 2015-03-12 | 2015-03-13 |  | 100% | Bill | Case | Kingston NY |  | Repair |
| 14 | Eaton silencer | 2d | 2015-03-18 | 2015-03-19 |  | 100% | Jason/CJ |  | Arden NC | ME | Install |
| 15 | L242 site review | 3d | 2015-03-16 | 2015-03-18 |  | 100% | Bill/Halb | 21713 | Spokane WA | MH | Eng Review |
| 16 | Butler Rosedale | 11d | 2015-03-17 | 2015-03-28 |  | 100% | Mike/Mark | 22345 | Pittsburg PA | MC | Install |
| 17 | Honda Canada | 5d | 2015-03-18 | 2015-03-23 |  | 90% | Contractor | 22267 | Canada | BS | Contractor |
| 18 | Utica Alloy CASE | 2d | 2015-03-23 | 2015-03-24 |  | 100% | Jason CJ | 1529 | Monroe NC | ME | Install |
| 19 | Altec | 1d | 2015-03-26 | 2015-03-26 |  | 100% | Jason/CJ |  |  |  |  |
| 20 | Lincoln | 1d | 2015-03-27 | 2015-03-27 |  | 100% | Jason/CJ |  |  |  |  |
| 21 | Johnson tech | 1d | 2015-03-31 | 2015-03-31 |  | 100% | Daniel |  | NC |  | Repair |
| 22 | Cornell Iron Airgas | 2d | 2015-04-06 | 2015-04-07 |  | 100% | Jason/CJ | 22435 | Mountain Top PA | MC | Install |
| 23 | Curtis Niagra | 2d | 2015-04-07 | 2015-04-08 |  | 100% | Jason/CJ |  | Buffalo NY | ES | Install |
| 24 | Johnson Tech | 1d | 2015-04-07 | 2015-04-07 |  | 100% | Daniel/Mark | Case | NC |  | Repair |
| 25 | PA Rail gauges | 1d | 2015-04-09 | 2015-04-09 |  | 100% | Jason/CJ |  | Mercer PA |  |  |
| 26 | Rosedale leak | 1d | 2015-04-09 | 2015-04-09 |  | 100% | Jason/CJ |  | Pittsburg PA | MC | Repair |
| 27 | MasterBrand | 2d | 2015-04-11 | 2015-04-13 |  | 100% | Jas/CJ | 21869 | Kinston NC | ukn | Install |
| 28 | Wolftec asses | 1d | 2015-04-14 | 2015-04-14 |  | 100% | Contractor |  |  | MC | Site asses |
| 29 | TENN Tech | 1d | 2015-04-15 | 2015-04-15 |  | 100% | Mike/Mark | case | TN |  | Install |
| 30 | Schaeffler | 1d | 2015-04-16 | 2015-04-16 |  | 100% | Mike/Mark | 22768 | Cheraw SC | ME | Repair |
| 31 | National mach | 1d | 2015-04-18 | 2015-04-18 |  | 100% | Mike |  | Lapeer MI | ES | PM |
| 32 | Sirchie | 1d | 2015-04-21 | 2015-04-21 |  | 100% | Daniel | 22785 | Youngsville NC | ME | Install |
| 33 | GKN Driveline | 1d | 2015-04-21 | 2015-04-21 |  | 100% | Bill |  | Mebane NC | ME | Assess |
| 34 | JCC silencer | 1d | 2015-04-21 | 2015-04-21 |  | 100% | MIke/Mark |  |  |  |  |
| 35 | Duer coil | 1d | 2015-04-22 | 2015-04-22 |  | 100% | Mike/Mark |  | Greer SC |  |  |
| 36 | Wolftec | 3d | 2015-04-23 | 2015-04-25 |  | 66% | Contractor | 1537 | NY | MC | breaker inst |
| 37 | Local 92 | 8d | 2015-04-20 | 2015-04-28 |  | 80% | Mike/Mark | 21709 | Bloomington CA | ES | Install |
| 38 | Spanda Collectr | 5d | 2015-04-28 | 2015-05-02 |  | 10% | Mike/CJ | 22050 | Sacremento CA |  | Install |
| 39 | PPL Airgas | 3d | 2015-04-28 | 2015-04-30 |  | 50% | Daniel/Dusty |  | PA | MC |  |
| 40 | Lynar | 1d | 2015-05-01 | 2015-05-01 | 39 |  | Daniel |  | PA | MC | pick up duct |
| 41 | Plumb & pipe | 1d | 2015-05-05 | 2015-05-05 |  |  | Bill |  | PA | MC | Assess |
| 42 | ATI | 1d | 2015-05-06 | 2015-05-06 | 41 |  | Bill |  | PA | MC | Assess |
| 43 | Schaeffler | 1d | 2015-05-06 | 2015-05-06 |  |  | Daniel |  | Cheraw SC | MC | Assess |
| 44 | General distL11 | 5d | 2015-05-11 | 2015-05-15 |  |  |  | 20799 |  |  | PM |
| 45 | Local 242 | 7d | 2015-05-11 | 2015-05-18 |  |  |  | 21713 | Spokane WA | ES | PM |
| 46 | Erwin Junk PM | 5d | 2015-05-11 | 2015-05-15 |  |  |  | 22545 | Robinsonville MS | ES | Install |
| 47 | Medtronics | 1d | 2015-02-02 | 2015-02-02 |  |  | Bill |  |  |  | Assess |
| 48 | ATI | 1d | 2015-06-29 | 2015-06-29 |  |  | Bill |  | Pittsburg | MC | Install |
| 49 | Medtronics | 10d | 2015-05-27 | 2015-06-06 |  |  | Bill or Daniel |  |  |  |  |
| 50 | Local 04 | 7d | 2015-05-27 | 2015-06-03 |  |  | Jason/CJ | 21829 | Page AZ | ES | PM |
| 51 | SLouisianna CC | 10d | 2015-05-27 | 2015-06-06 |  |  | Mike/Mark | 22578 | New Iberia LA | KB | Install |
| 52 | Mike Vacation | 6d | 2015-06-26 | 2015-07-02 |  |  | Mike Taylor |  |  |  | Vacation |
| 53 | Rosedale DDTs | 2d | 2015-06-29 | 2015-06-30 |  |  |  |  | Pittsburg PA | MC | Install |
| 54 | Plumbers PIPE | 2d | 2015-06-29 | 2015-06-30 |  |  |  | 22152 | Landover MD | MC | Construct |
| 55 | P&P booths | 7d | 2015-07-10 | 2015-07-17 |  |  |  | 22152 |  | MC | Install |
| 56 | Doosan PM | 2d | 2015-04-27 | 2015-04-28 |  |  | Bill? | 21920 | Mexico | ES | PM |
| 57 | Machine tech | 3d | 2015-04-06 | 2015-04-08 |  |  | Contractor |  |  |  |  |
| 58 | Cubic Machine PM | 5d | 2015-04-20 | 2015-04-24 |  |  | Contractor | 22482 | Brea CA | MH | PM |
| 59 | RB&W | 3d | 2015-04-06 | 2015-04-08 |  |  | Contractor |  | Canada | BS |  |
| 60 | JR Auto JCI cell 4 | 5d | 2015-04-27 | 2015-05-01 |  |  | Bill |  | Mexico | ES | PM |
| 61 | Gilford Tech | 1d | 2015-05-04 | 2015-05-04 |  |  | Jason | 21946 | Jamestown NC |  | PM |
| 62 | Johnson Control | 5d | 2015-07-06 | 2015-07-10 |  |  |  | Case | Battle creek MI | FJ/ES | Install |
| 63 | Roosevelt High | 5d | 2015-09-08 | 2015-09-12 |  |  | Contractor |  |  |  |  |
| 64 | AP Wyoming | 1d | 2014-12-01 | 2014-12-01 |  |  | Contractor |  | WY |  |  |
| 65 | HB Construction | 5d | 2015-11-02 | 2015-11-06 |  |  |  | 21379 | Bernalillo NM | ukn | Install |
| 66 | Chevron | 1d | 2015-01-05 | 2015-01-05 |  |  |  |  | Richmond CA |  | Install |
| 67 | Johnson Control | 1d | 2015-01-01 | 2015-01-01 |  |  |  | 22748 | Mexico | ES |  |
