# San Mao open projects

Schedule from GanttProject, 2015-02-02 to 2015-08-20.

## Calendars

- Project calendar: Mon-Fri working; Sat-Sun off.

## Schedule

| ID | WBS | Task | Type | Duration | Start | Finish | Predecessors |
| --- | --- | --- | --- | --- | --- | --- | --- |
| 1 | 1 | **College of Charleston** |  | 68d | 2015-03-05 | 2015-06-08 |  |
| 2 | 1.1 | Fabrication |  | 41d | 2015-03-05 | 2015-04-30 |  |
| 3 | 1.2 | Ship to Wilm port |  | 20d | 2015-05-01 | 2015-05-28 | 2 |
| 4 | 1.3 | Customs at Wilm |  | 5d | 2015-05-29 | 2015-06-04 | 3 |
| 5 | 1.4 | Transit to customer |  | 2d | 2015-06-05 | 2015-06-08 | 4 |
| 6 | 1.5 | Delivery | milestone | 0d | 2015-06-09 | 2015-06-09 | 5 |
| 7 | 2 | **Randolph** |  | 51d | 2015-03-31 | 2015-06-09 |  |
| 8 | 2.1 | Fabrication |  | 23d | 2015-03-31 | 2015-04-30 |  |
| 9 | 2.2 | Ship to Wilm port |  | 20d | 2015-05-01 | 2015-05-28 | 8 |
| 10 | 2.3 | Customs at wilm |  | 5d | 2015-05-29 | 2015-06-04 | 9 |
| 11 | 2.4 | Transit to customer |  | 3d | 2015-06-05 | 2015-06-09 | 10 |
| 12 | 2.5 | Delivery | milestone | 0d | 2015-06-10 | 2015-06-10 | 11 |
| 13 | 3 | **Rosedale DDTs** |  | 74d | 2015-03-16 | 2015-06-25 |  |
| 14 | 3.1 | Fabrication |  | 37d | 2015-03-16 | 2015-05-05 |  |
| 15 | 3.2 | Ship to Wim port |  | 30d | 2015-05-06 | 2015-06-16 | 14 |
| 16 | 3.3 | Customs at Wilm |  | 5d | 2015-06-17 | 2015-06-23 | 15 |
| 17 | 3.4 | Transit to PA |  | 2d | 2015-06-24 | 2015-06-25 | 16 |
| 18 | 3.5 | Delivery | milestone | 0d | 2015-06-26 | 2015-06-26 | 17 |
| 19 | 4 | **AP Wyoming** |  | 58d | 2015-04-14 | 2015-07-02 |  |
| 20 | 4.1 | Fabrication |  | 29d | 2015-04-14 | 2015-05-22 |  |
| 21 | 4.2 | Ship to Wilm port |  | 20d | 2015-05-25 | 2015-06-19 | 20 |
| 22 | 4.3 | Customs at Wilm |  | 5d | 2015-06-22 | 2015-06-26 | 21 |
| 23 | 4.4 | Transit to customer |  | 4d | 2015-06-29 | 2015-07-02 | 22 |
| 24 | 4.5 | Delivery | milestone | 0d | 2015-07-03 | 2015-07-03 | 23 |
| 25 | 4.6 | Ship to LA port |  | 15d | 2015-05-25 | 2015-06-12 | 20 |
| 26 | 4.7 | Customs at LA |  | 7d | 2015-06-15 | 2015-06-23 | 25 |
| 27 | 4.8 | Transit to customer |  | 3d | 2015-06-24 | 2015-06-26 | 26 |
| 28 | 4.9 | Delivery | milestone | 0d | 2015-06-29 | 2015-06-29 | 27 |

| ID | WBS | Task | Type | Duration | Start | Finish | Predecessors |
| --- | --- | --- | --- | --- | --- | --- | --- |
| 29 | 5 | **Plumbers and Pipefitters** |  | 67d | 2015-04-07 | 2015-07-08 |  |
| 30 | 5.1 | Release for Production |  | 1d | 2015-04-07 | 2015-04-07 |  |
| 31 | 5.2 | Fabrication |  | 37d | 2015-04-08 | 2015-05-28 | 30 |
| 32 | 5.3 | Ship to Wilm port |  | 20d | 2015-05-29 | 2015-06-25 | 31 |
| 33 | 5.4 | Customs at Wilm |  | 5d | 2015-06-26 | 2015-07-02 | 32 |
| 34 | 5.5 | Re-crate |  | 2d | 2015-07-03 | 2015-07-06 | 33 |
| 35 | 5.6 | Transit to customer |  | 2d | 2015-07-07 | 2015-07-08 | 34 |
| 36 | 5.7 | Delivery | milestone | 0d | 2015-07-09 | 2015-07-09 | 35 |
| 37 | 6 | **Mich Prison** |  | 72d | 2015-04-07 | 2015-07-15 |  |
| 38 | 6.1 | Fabrication |  | 43d | 2015-04-07 | 2015-06-04 |  |
| 39 | 6.2 | Ship to Wilm port |  | 20d | 2015-06-05 | 2015-07-02 | 38 |
| 40 | 6.3 | Customs at Wilm |  | 5d | 2015-07-03 | 2015-07-09 | 39 |
| 41 | 6.4 | Ship to customer |  | 4d | 2015-07-10 | 2015-07-15 | 40 |
| 42 | 6.5 | Delivery | milestone | 0d | 2015-07-16 | 2015-07-16 | 41 |
| 43 | 7 | **Groathouse/Roosevelt** |  | 76d | 2015-04-06 | 2015-07-20 |  |
| 44 | 7.1 | Release for production |  | 20d | 2015-04-06 | 2015-05-01 |  |
| 45 | 7.2 | Fabrication |  | 30d | 2015-05-04 | 2015-06-12 | 44 |
| 46 | 7.3 | Ship to LA port |  | 15d | 2015-06-15 | 2015-07-03 | 45 |
| 47 | 7.4 | LA Customs |  | 7d | 2015-07-06 | 2015-07-14 | 46 |
| 48 | 7.5 | Transit to customer |  | 4d | 2015-07-15 | 2015-07-20 | 47 |
| 49 | 7.6 | Delivery | milestone | 0d | 2015-07-21 | 2015-07-21 | 48 |
| 50 | 8 | **McCown Gordon** |  | 82d | 2015-04-20 | 2015-08-11 |  |
| 51 | 8.1 | Fabrication |  | 53d | 2015-04-20 | 2015-07-01 |  |
| 52 | 8.2 | Ship to Wilm port |  | 20d | 2015-07-02 | 2015-07-29 | 51 |
| 53 | 8.3 | Customs at Wilm |  | 5d | 2015-07-30 | 2015-08-05 | 52 |
| 54 | 8.4 | Transit to customer |  | 4d | 2015-08-06 | 2015-08-11 | 53 |
| 55 | 8.5 | Delivery | milestone | 0d | 2015-08-12 | 2015-08-12 | 54 |

| ID | WBS | Task | Type | Duration | Start | Finish | Predecessors |
| --- | --- | --- | --- | --- | --- | --- | --- |
| 56 | 9 | **Gala** |  | 77d | 2015-05-05 | 2015-08-19 |  |
| 57 | 9.1 | Gala_Submittals |  | 5d | 2015-05-05 | 2015-05-11 |  |
| 58 | 9.2 | Gala_Fabrication |  | 43d | 2015-05-12 | 2015-07-09 | 57 |
| 59 | 9.3 | Gala_Ship to Wilm port |  | 20d | 2015-07-10 | 2015-08-06 | 58 |
| 60 | 9.4 | Gala_Customs at Wilm |  | 5d | 2015-08-07 | 2015-08-13 | 59 |
| 61 | 9.5 | Gala_Ship to customer |  | 4d | 2015-08-14 | 2015-08-19 | 60 |
| 62 | 9.6 | Gala_Delivery | milestone | 0d | 2015-08-20 | 2015-08-20 | 61 |
| 63 | 10 | San Bernardino |  | 1d | 2015-03-30 | 2015-03-30 |  |
| 64 | 11 | Kodiak HS |  | 1d | 2015-04-06 | 2015-04-06 |  |
| 65 | 12 | task_247 |  | 1d | 2015-02-02 | 2015-02-02 |  |
| 66 | 13 | LEE |  | 1d | 2015-04-06 | 2015-04-06 |  |
| 67 | 14 | Johnson Cont |  | 1d | 2015-04-06 | 2015-04-06 |  |
| 68 | 15 | task_19 |  | 1d | 2015-04-06 | 2015-04-06 |  |
| 69 | 16 | task_20 |  | 1d | 2015-04-06 | 2015-04-06 |  |
| 70 | 17 | task_21 |  | 1d | 2015-04-06 | 2015-04-06 |  |
| 71 | 18 | task_22 |  | 1d | 2015-04-06 | 2015-04-06 |  |
| 72 | 19 | task_23 |  | 1d | 2015-04-06 | 2015-04-06 |  |
| 73 | 20 | task_24 |  | 1d | 2015-04-06 | 2015-04-06 |  |
| 74 | 21 | task_25 |  | 1d | 2015-04-06 | 2015-04-06 |  |
| 75 | 22 | task_26 |  | 1d | 2015-04-06 | 2015-04-06 |  |
| 76 | 23 | task_27 |  | 1d | 2015-04-06 | 2015-04-06 |  |
| 77 | 24 | task_28 |  | 1d | 2015-04-06 | 2015-04-06 |  |
| 78 | 25 | Copy_task_20 |  | 1d | 2015-04-06 | 2015-04-06 |  |
| 79 | 26 | Copy_task_21 |  | 1d | 2015-04-06 | 2015-04-06 |  |
| 80 | 27 | Copy_task_22 |  | 1d | 2015-04-06 | 2015-04-06 |  |
| 81 | 28 | Copy_task_23 |  | 1d | 2015-04-06 | 2015-04-06 |  |
| 82 | 29 | Copy_task_24 |  | 1d | 2015-04-06 | 2015-04-06 |  |
| 83 | 30 | Copy_task_25 |  | 1d | 2015-04-06 | 2015-04-06 |  |
| 84 | 31 | Copy_task_26 |  | 1d | 2015-04-06 | 2015-04-06 |  |
| 85 | 32 | Copy_task_27 |  | 1d | 2015-04-06 | 2015-04-06 |  |
| 86 | 33 | Copy_task_28 |  | 1d | 2015-04-06 | 2015-04-06 |  |
| 87 | 34 | Copy_task_29 |  | 1d | 2015-04-06 | 2015-04-06 |  |
| 88 | 35 | Copy_task_30 |  | 1d | 2015-04-06 | 2015-04-06 |  |
| 89 | 36 | Copy_task_31 |  | 1d | 2015-04-06 | 2015-04-06 |  |
| 90 | 37 | Copy_task_32 |  | 1d | 2015-04-06 | 2015-04-06 |  |
| 91 | 38 | Copy_task_33 |  | 1d | 2015-04-06 | 2015-04-06 |  |
| 92 | 39 | task_29 |  | 1d | 2015-04-06 | 2015-04-06 |  |
| 93 | 40 | task_30 |  | 1d | 2015-04-06 | 2015-04-06 |  |
| 94 | 41 | task_31 |  | 1d | 2015-04-06 | 2015-04-06 |  |
| 95 | 42 | task_32 |  | 1d | 2015-04-06 | 2015-04-06 |  |
| 96 | 43 | task_33 |  | 1d | 2015-04-06 | 2015-04-06 |  |
